# Planning prévi 090920

Schedule from MS Project, 2026-08-31 to 2027-01-15, 7 hours a day.

## Calendars

- Standard: Mon-Fri 09:00-12:00, 14:00-18:00; Sat-Sun off.

## Resources

| Resource |
| --- |
| 4 |

## Schedule

| ID | WBS | Task | Duration | Start | Finish | Predecessors | Total slack | Free slack | Constraint |
| --- | --- | --- | --- | --- | --- | --- | --- | --- | --- |
| 1 | 1 | **PHASE PREPARATION** | 30d | 2026-08-31 | 2026-10-09 |  | 0d |  |  |
| 2 | 1.1 | Rédaction du PdR en validation par les organismes | 30d | 2026-08-31 | 2026-10-09 |  | 70d |  | start no earlier than 2026-08-31 |
| 3 | 1.2 | Installation de chantier et travaux préparatoires (accès chantier, base vie, raccordements eau/élec…) | 20d | 2026-08-31 | 2026-09-25 |  | 0d |  | start no earlier than 2026-08-31 |
| 4 | 2 | **PHASE TRAVAUX** | 80d | 2026-09-28 | 2027-01-15 |  | 0d |  |  |
| 5 | 2.1 | **Bâtiments 24/18-81: Poterie + Garage et Atelier Cours et Jardins** | 35d | 2026-09-28 | 2026-11-13 |  | 25d |  |  |
| 6 | 2.1.1 | curage | 10d | 2026-09-28 | 2026-10-09 | 3 | 25d | 0d | start no earlier than 2024-07-29 |
| 7 | 2.1.2 | Désamiantage + déplombage | 10d | 2026-10-12 | 2026-10-23 | 6 | 45d | 0d |  |
| 8 | 2.1.3 | Démolition + évacuations | 15d | 2026-10-26 | 2026-11-13 | 7 | 45d |  | start no earlier than 2024-04-22 |
| 9 | 2.2 | **Bâtiments 23 : Les Glycines** | 45d | 2026-10-12 | 2026-12-11 |  | 25d |  |  |
| 10 | 2.2.1 | curage | 20d | 2026-10-12 | 2026-11-06 | 6 | 25d | 0d | start no earlier than 2024-07-29 |
| 11 | 2.2.2 | Désamiantage + déplombage | 5d | 2026-11-09 | 2026-11-13 | 10 | 25d | 0d |  |
| 12 | 2.2.3 | Démolition + évacuations | 20d | 2026-11-16 | 2026-12-11 | 11 | 25d |  | start no earlier than 2024-04-22 |
| 13 | 2.3 | **Bâtiment 19 : Les Mélèzes** | 55d | 2026-09-28 | 2026-12-11 |  | 0d |  |  |
| 14 | 2.3.1 | curage | 20d | 2026-09-28 | 2026-10-23 | 3 | 0d |  | start no earlier than 2024-07-29 |
| 15 | 2.3.2 | Désamiantage + déplombage | 15d | 2026-10-26 | 2026-11-13 | 14 | 0d |  |  |
| 16 | 2.3.3 | Démolition + évacuations | 20d | 2026-11-16 | 2026-12-11 | 15 | 0d |  | start no earlier than 2026-09-14 |
| 17 | 2.4 | **Bâtiments 17 : Atelier Mécanique + Annexes** | 40d | 2026-10-26 | 2026-12-18 |  | 0d |  |  |
| 18 | 2.4.1 | Curage | 15d | 2026-10-26 | 2026-11-13 | 14 | 0d |  | start no earlier than 2024-07-29 |
| 19 | 2.4.2 | Désamiantage + déplombage | 10d | 2026-11-16 | 2026-11-27 | 18 | 0d |  |  |
| 20 | 2.4.3 | Démolition + évacuations | 15d | 2026-11-30 | 2026-12-18 | 19 | 0d |  | start no earlier than 2024-04-22 |
| 21 | 2.5 | **Bâtiments 20/21/58 : Chapelle + Salle polyvalente** | 35d | 2026-11-16 | 2027-01-01 |  | 10d |  |  |
| 22 | 2.5.1 | Curage | 15d | 2026-11-16 | 2026-12-04 | 18 | 10d | 0d | start no earlier than 2024-07-29 |
| 23 | 2.5.2 | Désamiantage + déplombage | 5d | 2026-12-07 | 2026-12-11 | 22 | 10d | 0d |  |
| 24 | 2.5.3 | Démolition + évacuations | 15d | 2026-12-14 | 2027-01-01 | 23 | 10d |  | start no earlier than 2024-04-22 |
| 25 | 2.6 | Démolitions des enrobés | 10d | 2026-12-21 | 2027-01-01 | 20 | 0d |  |  |
| 26 | 2.7 | Terrassements | 25d | 2026-12-14 | 2027-01-15 | 16 | 0d |  |  |
| 27 | 2.8 | Réception des travaux | 1d | 2027-01-04 | 2027-01-04 | 25 | 0d |  | start no earlier than 2024-07-29 |
| 28 | 2.9 | Levées des réserves | 9d | 2027-01-05 | 2027-01-15 | 27 | 0d |  |  |
